# 2008 Schedule Template Rev. 3

Schedule from MS Project, 2009-02-23 to 2009-08-21, scheduled back from the finish.
Jefferson Lab

## Calendars

- Standard: Mon-Fri 08:00-12:00, 13:00-17:00; Sat-Sun off.

## Resources

| Resource |
| --- |
| RADCON |
| Alignment Group |
| Hall-C tech's |
| ACC tech's |
| Hall C Tech's |
| Cryo Target Tech's |
| Hall C Tech's / ESH&Q |
| Experimenters |
| Hall C Tech's / RADCO |
| Hall C Tech's / RADCON |
| Hall C Tech's / Experim. |
| Target Group / Experimenters |
| Target Group / Experim. |
| Alignment Group / Hall C Tech's |
| Align. Group / Hall C Tech's |
| Users/Hall C tech's |
| RADCON tech's |
| Survey group |
| Eric Christy / Paul Hood |
| Hall C Tech's / Hamlet |
| Design/Eng group |
| Lockwood / Hall C Tech's |
| Lockwood |
| Contractor |
| Hall C Tech's / Electri. |
| Experimenters/ H C Tech's |
| Miscellaneous |
| Target Group / Cryo group |
| Hall-C tech's / design group |
| Hall-C techs / experimenters |
| Hall-C tech's / contractor |
| Hall-C tech's / align group |
| Hall-C techs / align group |
| Hall-C techs |
| Electrical contractor |
| Acc. Vac. Tech's |
| Hall C Tech's / Greg Adams |
| ACC Tech's / Hall C Tech's |
| Installation / User Groups |
| Installation Groups |
| Hall C Tech's & IEHS |

## Schedule

| ID | Task | Duration | Start | Finish | Total slack | Free slack | Constraint | Resources | Work | Hard Hat & Safety Shoe Area | Text7 | Text2 | Text12 | Text17 | Text11 | Text16 |
| --- | --- | --- | --- | --- | --- | --- | --- | --- | --- | --- | --- | --- | --- | --- | --- | --- |
| 1 | 2009 Mar. to Aug. HES-HKS installation and commissioning | 118d | 2009-03-11 | 2009-08-21 | 12d | 0d | start no later than 2009-03-11 |  |  |  |  |  |  |  |  |  |
| 2 | Meeting: C Staff, RADCON, ALIGN, ACC, EH&S, Target group | 0.1d | 2009-03-02 | 2009-03-02 | 5d | 0d | start no later than 2009-03-02 | Installation Groups | 0.8h |  |  |  |  |  |  |  |
| 3 | Beam line and target Radiation cool down ( RWP ?) | 6d | 2009-03-10 | 2009-03-17 | 11d | 0d | finish no later than 2009-03-17 | RADCON | 48h |  |  |  |  |  |  |  |
| 4 | Prepare safety / work documentation for this schedule | 12d | 2009-02-23 | 2009-03-10 | 0d |  | finish no later than 2009-03-10 | Hall C Tech's | 96h |  |  |  |  |  |  |  |
| 5 | SANE decommissioning March 10 to March 31 | 16d | 2009-03-10 | 2009-03-31 | 11d | 0d | finish no later than 2009-03-31 |  |  |  |  |  |  |  |  |  |
| 6 | Clear truck ramp, move in areal platforms, tools and equipment into Hall | 1d | 2009-03-10 | 2009-03-10 | 11d | 0d | start no later than 2009-03-10 | Hall C Tech's | 8h | ITHA Req'd | 1 |  |  |  |  |  |
| 7 | RADCON support required | 1d | 2009-03-10 | 2009-03-10 | 11d | 0d | start no later than 2009-03-10 | RADCON | 8h | ITHA Req'd | 0 |  |  |  |  |  |
| 8 | Move HMS to 45 deg. | 0.2d | 2009-03-10 | 2009-03-10 | 11d | 0d | start no later than 2009-03-10 | Design/Eng group | 1.6h | ITHA Req'd | 1 |  |  |  |  |  |
| 9 | Remove He beam line and shield wall to clear space for new concrete pad | 3d | 2009-03-11 | 2009-03-13 | 12d | 0d | start no later than 2009-03-11 | Hall C Tech's | 24h | ITHA Req'd | 2 | Req'd | RWP ? | Hall C |  |  |
| 10 | RADCON support required | 3d | 2009-03-11 | 2009-03-13 | 12d | 0d | finish no later than 2009-03-13 | RADCON | 24h | ITHA Req'd | 0 |  |  |  |  |  |
| 11 | Move He bag and unistrut to storage container | 1d | 2009-03-16 | 2009-03-16 | 15d | 0d | start no later than 2009-03-16 | Hall C Tech's | 8h | ITHA Req'd | 1 |  |  |  |  |  |
| 12 | RADCON support required | 1d | 2009-03-16 | 2009-03-16 | 15d | 0d | start no later than 2009-03-16 | RADCON | 8h | ITHA Req'd | 0 |  |  |  |  |  |
| 13 | Open SOS doors and secure in place, then release Hydraulic pressure | 1d | 2009-03-18 | 2009-03-18 | 17d | 0d | start no later than 2009-03-18 | Hall C Tech's | 8h | ITHA Req'd | 2 | Req'd |  |  |  |  |
| 14 | Drain all 350 gal Hydraulic oil form tank and pipes | 1d? | 2009-03-19 | 2009-03-19 | 18d | 0d | start no later than 2009-03-19 | Hall C Tech's & IEHS | 8h | THA Req'd | 2 |  | TOSP ? |  | Req'd |  |
| 15 | RADCON support required | 1d | 2009-03-19 | 2009-03-19 | 18d | 0d | start no later than 2009-03-19 | RADCON | 8h | ITHA Req'd | 0 |  |  |  |  |  |
| 16 | Clear roof of shield hut and remove roof beams | 3d | 2009-03-19 | 2009-03-23 | 18d | 0d | start no later than 2009-03-19 | Hall C Tech's | 24h | ITHA Req'd | 2 |  | Lift Plan Req'd | Hall C |  |  |
| 17 | Disconnect and remover all cooling fans | 1d? | 2009-03-23 | 2009-03-23 | 20d | 0d | start no later than 2009-03-23 | Hall C Tech's | 8h | ITHA Req'd | 2 |  |  | Local |  |  |
| 18 | Bring red cable rack into Hall C and place near shield hut | 1d? | 2009-03-23 | 2009-03-23 | 20d | 0d | start no later than 2009-03-23 | Hall C Tech's | 8h | ITHA Req'd | 1 |  |  | Hall C |  |  |
| 19 | Disconnect all cables from BIG CAL, roll up and place on storage rack | 5d? | 2009-03-12 | 2009-03-18 | 13d | 0d | start no later than 2009-03-12 | Experimenters | 40h | ITHA Req'd | 1 |  |  |  |  |  |
| 20 | RADCON support required | 2d | 2009-03-16 | 2009-03-17 | 15d | 0d | start no later than 2009-03-16 | RADCON | 16h | ITHA Req'd | 0 |  |  |  |  |  |
| 21 | Remove blowers and legs then transport BIG CAL to the Test Lab | 2d | 2009-03-17 | 2009-03-18 | 16d | 0d | start no later than 2009-03-17 | Hall C Tech's / Experim. | 16h | THA Req'd | 2 |  |  | Hall C&T.L. |  |  |
| 22 | RADCON support required | 2d | 2009-03-17 | 2009-03-18 | 16d | 0d | start no later than 2009-03-17 | RADCON | 16h | ITHA Req'd | 0 |  |  |  |  |  |
| 23 | Disconnect and disassemble SANE electronics in shield hut | 3d? | 2009-03-18 | 2009-03-20 | 17d | 0d | finish no later than 2009-03-20 | Experimenters | 24h | ITHA Req'd | 1 |  |  |  |  |  |
| 24 | Pack elec. into boxes and move electronics and racks to storage | 2d? | 2009-03-23 | 2009-03-24 | 20d | 0d | finish no later than 2009-03-24 | Experimenters/ H C Tech's | 16h | ITHA Req'd | 1 |  |  |  |  |  |
| 25 | RADCON support required | 2d | 2009-03-23 | 2009-03-24 | 20d | 0d | start no later than 2009-03-23 | RADCON | 16h | ITHA Req'd | 0 |  |  |  |  |  |
| 26 | Crane out GEP/SAN electronic platform and move to storage | 1d? | 2009-03-25 | 2009-03-25 | 22d | 0d | finish no later than 2009-03-25 | Hall-C tech's | 8h | THA Req'd | 2 |  |  | Hall C |  |  |
| 27 | RADCON support required | 1d | 2009-03-25 | 2009-03-25 | 22d | 0d | start no later than 2009-03-25 | RADCON | 8h | ITHA Req'd | 0 |  |  |  |  |  |
| 28 | Remove cable storage rack from Hall C to storage place | 1d? | 2009-03-25 | 2009-03-25 | 22d | 0d | start no later than 2009-03-25 | Hall C Tech's | 8h | ITHA Req'd | 2 |  |  | Hall C |  |  |
| 29 | RADCON support required | 1d | 2009-03-25 | 2009-03-25 | 22d | 0d | start no later than 2009-03-25 | RADCON | 8h | ITHA Req'd | 0 |  |  |  |  |  |
| 30 | Disassemble and move Cerenkov detector and stand to storage | 1d | 2009-03-26 | 2009-03-26 | 23d | 0d | start no later than 2009-03-26 | Hall C Tech's / Experim. | 8h | ITHA Req'd | 2 |  |  | Local |  |  |
| 31 | RADCON support required | 1d | 2009-03-26 | 2009-03-26 | 23d | 0d | start no later than 2009-03-26 | RADCON | 8h | ITHA Req'd | 0 |  |  |  |  |  |
| 32 | Remove all lead shield walls from pivot and support beam | 2d | 2009-03-27 | 2009-03-30 | 24d | 0d | start no later than 2009-03-27 | Hall C Tech's | 16h | THA Req'd | 2 |  |  | Local |  |  |
| 33 | RADCON support required | 2d | 2009-03-27 | 2009-03-30 | 24d | 0d | start no later than 2009-03-27 | RADCON | 16h | ITHA Req'd | 0 |  |  |  |  |  |
| 34 | Complete concrete pad for HKS dipole | 7d | 2009-03-17 | 2009-03-25 | 16d | 0d | finish no later than 2009-03-25 | Contractor | 56h |  |  |  |  |  |  |  |
| 35 | Layout phase 2 of the 9.5" concrete pad extension location of the HKS dipole | 1d | 2009-03-16 | 2009-03-16 | 15d | 0d | start no later than 2009-03-16 | Alignment Group / Hall C Tech's | 8h | ITHA Req'd | 0 |  |  |  |  |  |
| 36 | Cover HMS rail section for phase 2 with plastic and foam | 3d | 2009-03-16 | 2009-03-18 | 15d | 0d | start no later than 2009-03-16 | Hall C Tech's | 24h | ITHA Req'd | 0 |  |  |  |  |  |
| 37 | Build concrete forms and anchor to floor | 3d | 2009-03-17 | 2009-03-19 | 16d | 0d | start no later than 2009-03-17 | Contractor | 24h | ITHA Req'd | 1 |  |  |  |  |  |
| 38 | Cut, bend and place rebar | 2d | 2009-03-19 | 2009-03-20 | 18d | 0d | start no later than 2009-03-19 | Contractor | 16h | ITHA Req'd | 1 |  |  |  |  |  |
| 39 | Pore concrete into forms, level and finish | 2d | 2009-03-23 | 2009-03-24 | 20d | 0d | start no later than 2009-03-23 | Contractor | 16h | ITHA Req'd | 2 |  |  |  |  |  |
| 40 | Remove concrete forms and clean up | 3d | 2009-03-25 | 2009-03-27 | 22d | 0d | finish no later than 2009-03-27 | Contractor | 24h | ITHA Req'd | 0 |  |  |  |  |  |
| 41 | Polarized Target disassembly and removal ( Dave Meekins) | 23d | 2009-03-16 | 2009-04-15 | 15d | 0d | finish no later than 2009-04-15 | Cryo Target Tech's | 184h |  |  |  |  |  |  |  |
| 42 | Warm up Cryo Target an vent scatting chamber | 4d | 2009-03-11 | 2009-03-16 | 12d | 0d | start no later than 2009-03-11 | Target Group / Experim. | 32h | ITHA Req'd | 0 |  |  |  |  |  |
| 43 | Target Radiation cool down period | 5d | 2009-03-11 | 2009-03-17 | 12d | 0d | finish no later than 2009-03-17 | RADCON | 40h | ITHA Req'd | 0 |  |  |  |  |  |
| 44 | When Cerenkov and lead wall is removed, install pivot extensions and railing | 1d | 2009-03-18 | 2009-03-18 | 17d | 0d | start no later than 2009-03-18 | Hall C Tech's | 8h | THA Req'd | 1 |  |  |  |  |  |
| 45 | RADCON support required | 1d | 2009-03-18 | 2009-03-18 | 17d | 0d | start no later than 2009-03-18 | RADCON | 8h | ITHA Req'd | 0 |  |  |  |  |  |
| 46 | Remove scatting chamber windows | 1d | 2009-03-19 | 2009-03-19 | 18d | 0d | start no later than 2009-03-19 | Cryo Target Tech's | 8h | ITHA Req'd | 1 |  |  |  |  |  |
| 47 | RADCON support required | 1d | 2009-03-19 | 2009-03-19 | 18d | 0d | start no later than 2009-03-19 | RADCON | 8h | ITHA Req'd | 0 |  |  |  |  |  |
| 48 | Post run survey of target cells ??? | 2d | 2009-03-20 | 2009-03-23 | 19d | 0d | start no later than 2009-03-20 | Alignment Group | 16h | ITHA Req'd | 1 |  |  |  |  |  |
| 49 | RADCON support required | 1d | 2009-03-20 | 2009-03-20 | 19d | 0d | start no later than 2009-03-20 | RADCON | 8h | ITHA Req'd | 0 |  |  |  |  |  |
| 50 | Crane in and place Groove 45' areal platform in place (beam left) | 0.2d | 2009-03-20 | 2009-03-20 | 19d | 0d | start no later than 2009-03-20 | Hall C Tech's | 1.6h | ITHA Req'd | 2 |  | C-08-014-L |  |  | 1 |
| 51 | Place 60' JLG (beam right) for U-tube operation | 0.2d | 2009-03-23 | 2009-03-23 | 20d | 0d | start no later than 2009-03-23 | Hall C Tech's | 1.6h | ITHA Req'd | 2 |  | C-08-015-L |  |  |  |
| 52 | Uncover upstream beam line shield wall for Neil Wilson | 1d? | 2009-03-24 | 2009-03-24 | 21d | 0d | start no later than 2009-03-24 | Hall C Tech's | 8h | ITHA Req'd | 2 | Req'd |  | Hall C |  |  |
| 53 | Disconnect plumbing and electronics from top of target | 1d | 2009-03-24 | 2009-03-24 | 21d | 0d | start no later than 2009-03-24 | Cryo Target Tech's | 8h | ITHA Req'd | 2 |  |  |  |  |  |
| 54 | Disconnect the refrigeration transfer lines and store on top of cable tray | 1d | 2009-03-25 | 2009-03-25 | 22d | 0d | start no later than 2009-03-25 | Cryo Target Tech's | 8h | ITHA Req'd | 1 |  |  |  |  |  |
| 55 | Tie back the plumbing and electrical lines for target | 1d | 2009-03-26 | 2009-03-26 | 23d | 0d | start no later than 2009-03-26 | Cryo Target Tech's | 8h | ITHA Req'd | 1 |  |  |  |  |  |
| 56 | Crane target from pivot and move to storage | 1d | 2009-03-27 | 2009-03-27 | 24d | 0d | start no later than 2009-03-27 | Cryo Target Tech's | 8h | ITHA Req'd | 2 |  |  |  |  |  |
| 57 | RADCON support required | 1d | 2009-03-27 | 2009-03-27 | 24d | 0d | start no later than 2009-03-27 | RADCON | 8h | ITHA Req'd | 0 |  |  |  |  |  |
| 58 | Remove target chamber from pivot | 1d? | 2009-03-30 | 2009-03-30 | 25d | 0d | start no later than 2009-03-30 | Cryo Target Tech's | 8h | ITHA Req'd | 1 |  |  |  |  |  |
| 59 | RADCON support required | 1d | 2009-03-30 | 2009-03-30 | 25d | 0d | start no later than 2009-03-30 | RADCON | 8h | ITHA Req'd | 0 |  |  |  |  |  |
| 60 | Place target on forklift and transfer it to EEL target group area | 1d | 2009-03-30 | 2009-03-30 | 25d | 0d | start no later than 2009-03-30 | Cryo Target Tech's | 8h | ITHA Req'd | 1 |  |  |  |  |  |
| 61 | Disconnect and remove He dewer from platform | 1d? | 2009-03-31 | 2009-03-31 | 26d | 0d | start no later than 2009-03-31 | Cryo Target Tech's | 8h | ITHA Req'd | 0 |  |  |  |  |  |
| 62 | Remove target rotation ring from from pivot target deck | 1d? | 2009-03-31 | 2009-03-31 | 26d | 0d | start no later than 2009-03-31 | Cryo Target Tech's | 8h | ITHA Req'd | 0 |  |  |  |  |  |
| 63 | Unbolt target deck, crane out and move to bone yard | 1d? | 2009-04-01 | 2009-04-01 | 27d | 0d | start no later than 2009-04-01 | Hall C Tech's | 8h | ITHA Req'd | 1 |  |  |  |  |  |
| 64 | RADCON support required | 1d | 2009-04-01 | 2009-04-01 | 27d | 0d | start no later than 2009-04-01 | RADCON | 8h | ITHA Req'd | 0 |  |  |  |  |  |
| 65 | Disassemble electronic racks and clear of the equipment deck | 1d? | 2009-04-01 | 2009-04-01 | 27d | 0d | start no later than 2009-04-01 | Cryo Target Tech's | 8h | ITHA Req'd | 1 |  |  |  |  |  |
| 66 | RADCON support required | 1d | 2009-03-30 | 2009-03-30 | 25d | 0d | start no later than 2009-03-30 | RADCON | 8h | ITHA Req'd | 0 |  |  |  |  |  |
| 67 | Cut staircase, unbolt from floor and move to bone yard | 1d? | 2009-03-30 | 2009-03-30 | 25d | 0d | start no later than 2009-03-30 | Hall C Tech's | 8h | ITHA Req'd | 1 |  |  |  |  |  |
| 68 | RADCON support required | 1d | 2009-03-30 | 2009-03-30 | 25d | 0d | start no later than 2009-03-30 | RADCON | 8h | ITHA Req'd | 0 |  |  |  |  |  |
| 69 | Unbolt equipment deck, crane out and move to bone yard | 1d? | 2009-04-01 | 2009-04-01 | 27d | 0d | start no later than 2009-04-01 | Hall C Tech's | 8h | ITHA Req'd | 1 |  |  |  |  |  |
| 70 | RADCON support required | 1d | 2009-04-01 | 2009-04-01 | 27d | 0d | start no later than 2009-04-01 | RADCON | 8h | ITHA Req'd | 0 |  |  |  |  |  |

| ID | Task | Duration | Start | Finish | Total slack | Free slack | Constraint | Resources | Work | Hard Hat & Safety Shoe Area | Text7 | Text17 | Text12 | Text8 |
| --- | --- | --- | --- | --- | --- | --- | --- | --- | --- | --- | --- | --- | --- | --- |
| 71 | Remove the rest of the lead shield boxes from pivot to storage | 1d? | 2009-04-02 | 2009-04-02 | 28d | 0d | start no later than 2009-04-02 | Hall C Tech's | 8h | ITHA Req'd | 1 | Local |  |  |
| 72 | RADCON support required | 1d | 2009-04-02 | 2009-04-02 | 28d | 0d | start no later than 2009-04-02 | RADCON | 8h | ITHA Req'd | 0 |  |  |  |
| 73 | Clear area and move HMS to largest angle possible | 1d? | 2009-04-03 | 2009-04-03 | 29d | 0d | start no later than 2009-04-03 | Hall-C tech's / design group | 8h | ITHA Req'd | 1 |  |  |  |
| 74 | HKS-HES complete installation | 7d | 2009-03-17 | 2009-03-25 | 16d | 0d | finish no later than 2009-03-25 | Contractor | 56h |  |  |  |  |  |
| 75 | Install new monuments, tie in and establish control | 2d? | 2009-03-30 | 2009-03-31 | 25d | 0d | finish no later than 2009-03-31 | Alignment Group / Hall C Tech's | 16h | ITHA Req'd | 0 |  |  |  |
| 76 | Layout position for HES magnet base | 1d? | 2009-04-01 | 2009-04-01 | 27d | 0d | start no later than 2009-04-01 | Alignment Group | 8h | ITHA Req'd | 0 |  |  |  |
| 77 | Roll HES magnets into position (roll on concrete, no steel plates needed) | 2d | 2009-04-01 | 2009-04-02 | 27d | 0d | start no later than 2009-04-01 | Hall C Tech's | 16h | THA Req'd | 1 |  |  |  |
| 78 | During HES move use only 3/4" steel strips, then jack up and remove strips | 2d | 2009-04-01 | 2009-04-02 | 27d | 0d | start no later than 2009-04-01 | Hall C Tech's | 16h | THA Req'd | 1 |  | Lift Plan for Hydr |  |
| 79 | Rough align magnet base | 1d? | 2009-04-02 | 2009-04-02 | 28d | 0d | start no later than 2009-04-02 | Align. Group / Hall C Tech's | 8h | ITHA Req'd | 0 |  |  |  |
| 80 | Layout concrete anchor location for new splitter stand ("do not place anchors) | 1d? | 2009-04-03 | 2009-04-03 | 29d | 0d | start no later than 2009-04-03 | Alignment Group | 8h | ITHA Req'd | 0 |  |  |  |
| 81 | Move power supply for HKS and for HES into Hall C | 1d? | 2009-04-02 | 2009-04-02 | 28d | 0d | start no later than 2009-04-02 | Hall C Tech's | 8h | ITHA Req'd | 1 | Hall C |  |  |
| 82 | Move Splitter stand, girder stand, beam line and EZ stands into Hall C | 1d? | 2009-04-03 | 2009-04-03 | 29d | 0d | start no later than 2009-04-03 | Hall C Tech's | 8h | ITHA Req'd | 1 | Hall C |  |  |
| 83 | Vacuum clean new concrete pad and seal concrete (with water base sealer) | 1d? | 2009-04-06 | 2009-04-06 | 30d | 0d | start no later than 2009-04-06 | Hall-C tech's | 8h | ITHA Req'd | 0 |  |  |  |
| 84 | Move steels plates for HKS magnet into position | 1d? | 2009-04-07 | 2009-04-07 | 31d | 0d | start no later than 2009-04-07 | Hall C Tech's | 8h | ITHA Req'd | 1 | Local |  |  |
| 85 | Layout position for HKS magnet base | 1d? | 2009-04-07 | 2009-04-07 | 31d | 0d | start no later than 2009-04-07 | Alignment Group | 8h | ITHA Req'd | 0 |  |  |  |
| 86 | Move HKS dipole into position, | 1d? | 2009-04-07 | 2009-04-07 | 31d | 0d | start no later than 2009-04-07 | Hall-C tech's | 8h | THA Req'd | 2 |  |  |  |
| 87 | Align and re-fiducialize HKS magnet assembly | 1d? | 2009-04-07 | 2009-04-07 | 31d | 0d | start no later than 2009-04-07 | Alignment Group | 8h | ITHA Req'd | 0 |  |  |  |
| 88 | Layout HKS shield hut and detector table position | 1d? | 2009-04-07 | 2009-04-07 | 31d | 0d | start no later than 2009-04-07 | Alignment Group | 8h | ITHA Req'd | 1 |  |  |  |
| 89 | Splitter magnet stand arrives, move to Hall C and bold into position | 1d? | 2009-04-08 | 2009-04-08 | 32d | 0d | start no later than 2009-04-08 | Hall C Tech's | 8h | ITHA Req'd | 1 |  |  |  |
| 90 | Align slitter magnet stand and secure | 1d? | 2009-04-09 | 2009-04-09 | 33d | 0d | start no later than 2009-04-09 | Align. Group / Hall C Tech's | 8h | ITHA Req'd | 0 |  |  |  |
| 91 | Crane lower half of splitter magnet onto stand and place on alignment jacks | 1d? | 2009-04-09 | 2009-04-09 | 33d | 0d | start no later than 2009-04-09 | Hall C Tech's / Experim. | 8h | THA req'd | 2 | Local |  |  |
| 92 | Install sieve slit on to splitter magnet vacuum chamber and connect to power | 1d? | 2009-04-10 | 2009-04-10 | 34d | 0d | start no later than 2009-04-10 | Hall C Tech's | 8h | ITHA Req'd | 2 | Local |  |  |
| 93 | Align and fiducialize HKS sieve slit (all positions) | 1d? | 2009-04-13 | 2009-04-13 | 35d | 0d | start no later than 2009-04-13 | Alignment Group | 8h | ITHA Req'd | 0 |  |  |  |
| 94 | Install sieve slit on to HES Q1 vacuum chamber and connect to power | 1d? | 2009-04-13 | 2009-04-13 | 35d | 0d | start no later than 2009-04-13 | Hall C Tech's | 8h | ITHA Req'd | 2 | Local |  |  |
| 95 | Align and fiducialize HES sieve slit (all positions) | 1d? | 2009-04-13 | 2009-04-13 | 35d | 0d | start no later than 2009-04-13 | Alignment Group | 8h | ITHA Req'd | 0 |  |  |  |
| 96 | Tilt HES magnet assembly into final position | 1d? | 2009-04-13 | 2009-04-13 | 35d | 0d | start no later than 2009-04-13 | Hall C Tech's | 8h | ITHA Req'd | 1 |  |  |  |
| 97 | Complete shield hut for 4 electronic racks & 2 power supply < Evening shift > | 2d | 2009-04-13 | 2009-04-14 | 35d | 0d | start no later than 2009-04-13 | Lockwood / Hall C Tech's | 16h | THA Req'd | 2 | Hall C |  |  |
| 98 | Final alignment HES magnets and sieve slit | 1d? | 2009-04-14 | 2009-04-14 | 36d | 0d | start no later than 2009-04-14 | Alignment Group | 8h | ITHA Req'd | 1 |  |  |  |
| 99 | Place splitter magnet upper half and bolt down | 1d? | 2009-04-14 | 2009-04-14 | 36d | 0d | finish no later than 2009-04-14 | Hall-C tech's | 8h | THA Req'd | 2 | Local |  |  |
| 100 | Align splitter magnet | 1d? | 2009-04-15 | 2009-04-15 | 37d | 0d | finish no later than 2009-04-15 | Alignment Group | 8h | ITHA Req'd | 1 |  |  |  |
| 101 | Assemble and install EHS magnet detector access platform and staircase | 1d? | 2009-04-15 | 2009-04-15 | 37d | 0d | finish no later than 2009-04-15 | Hall-C tech's | 8h | THA Req'd | 2 | Local |  |  |
| 102 | Place lower layer of shielding blocks around HES stand < Evening shift > | 2d | 2009-04-15 | 2009-04-16 | 37d | 0d | start no later than 2009-04-15 | Lockwood / Hall C Tech's | 16h | THA Req'd | 2 | Hall C |  |  |
| 103 | Establish alignment control in HES shield hut | 1d? | 2009-04-17 | 2009-04-17 | 39d | 0d | start no later than 2009-04-17 | Alignment Group | 8h | ITHA Req'd | 1 |  |  |  |
| 104 | Install DW magnet stand (downstream of splitter) | 1d? | 2009-04-17 | 2009-04-17 | 39d | 0d | start no later than 2009-04-17 | Hall C Tech's | 8h | ITHA Req'd | 1 |  |  |  |
| 105 | Connect vacuum chamber to HKS dipole | 1d? | 2009-04-20 | 2009-04-20 | 40d | 0d | start no later than 2009-04-20 | Hall C Tech's | 8h | ITHA Req'd | 1 |  |  |  |
| 106 | Place upper layer of shielding blocks around HES stand < Evening shift > | 2d | 2009-04-20 | 2009-04-21 | 40d | 0d | start no later than 2009-04-20 | Lockwood / Hall C Tech's | 16h | THA Req'd | 2 | Hall C |  |  |
| 107 | Install DW magnet and DW vacuum chamber | 1d? | 2009-04-21 | 2009-04-21 | 41d | 0d | start no later than 2009-04-21 | Hall C Tech's | 8h | ITHA Req'd | 2 | Local |  |  |
| 108 | Align DW magnet and vacuum chamber | 1d? | 2009-04-21 | 2009-04-21 | 41d | 0d | start no later than 2009-04-21 | Alignment Group | 8h | ITHA Req'd | 1 |  |  |  |
| 109 | Connect DW vacuum to splitter and HKS vacuum chamber | 2d | 2009-04-21 | 2009-04-22 | 41d | 0d | start no later than 2009-04-21 | Hall C Tech's | 16h | ITHA Req'd | 1 |  |  |  |
| 110 | Blank off beam line ends and leak check all connections | 2d | 2009-04-21 | 2009-04-22 | 41d | 0d | start no later than 2009-04-21 | Hall C Tech's | 16h | ITHA Req'd | 1 |  |  |  |
| 111 | Place the 2 HKS detector platforms in position and bolt down | 1d? | 2009-04-22 | 2009-04-22 | 42d | 0d | start no later than 2009-04-22 | Hall C Tech's | 8h | ITHA Req'd | 2 | Hall C |  |  |
| 112 | Place lower layer of shielding blocks around HKS detc table < Evening shift > | 2d | 2009-04-22 | 2009-04-23 | 42d | 0d | start no later than 2009-04-22 | Lockwood / Hall C Tech's | 16h | THA Req'd | 2 | Hall C |  |  |
| 113 | Establish alignment control in HKS shield hut | 1d? | 2009-04-24 | 2009-04-24 | 44d | 0d | start no later than 2009-04-24 | Alignment Group | 8h | ITHA Req'd | 1 |  |  |  |
| 114 | Layout and mark position for photon beam dump support stand | 1d? | 2009-04-24 | 2009-04-24 | 44d | 0d | start no later than 2009-04-24 | Alignment Group | 8h | ITHA Req'd | 1 |  |  |  |
| 115 | Install photon beam dump support stand | 1d? | 2009-04-23 | 2009-04-23 | 43d | 0d | start no later than 2009-04-23 | Hall C Tech's | 8h | ITHA Req'd | 1 | Local |  |  |
| 116 | Place Fission Chamber on support post, cane in and connect water cooler | 1d? | 2009-04-23 | 2009-04-23 | 43d | 0d | start no later than 2009-04-23 | Hall C Tech's | 8h | ITHA Req'd | 1 | Local |  |  |
| 117 | Align beam dump and secure | 1d? | 2009-04-24 | 2009-04-24 | 44d | 0d | start no later than 2009-04-24 | Alignment Group | 8h | ITHA Req'd | 1 |  |  |  |
| 118 | Place S-4 steel and 12 concrete wall blocks at photon dump < Evening shift > | 2d | 2009-04-27 | 2009-04-28 | 45d | 0d | start no later than 2009-04-27 | Lockwood / Hall C Tech's | 16h | THA Req'd | 2 | Hall C |  |  |
| 119 | Install platform for lead shielding next to DW magnet | 1d? | 2009-04-27 | 2009-04-27 | 45d | 0d | start no later than 2009-04-27 | Hall C Tech's | 8h | ITHA Req'd | 1 | Local |  |  |
| 120 | Place and anchor photon beam line support at VIP3H | 1d? | 2009-04-27 | 2009-04-27 | 45d | 0d | start no later than 2009-04-27 | Hall C Tech's | 8h | ITHA Req'd | 1 | Local |  |  |
| 121 | Layout and place YAG Viewer support stand | 1d? | 2009-04-27 | 2009-04-27 | 45d | 0d | start no later than 2009-04-27 | Hall C Tech's | 8h | ITHA Req'd | 1 | Local |  |  |
| 122 | Install beam line from splitter to Fission Chamber including YAG | 1d? | 2009-04-28 | 2009-04-28 | 46d | 0d | start no later than 2009-04-28 | Hall C Tech's | 8h | ITHA Req'd | 1 |  |  |  |
| 123 | Leak check photon beam line | 1d? | 2009-04-28 | 2009-04-28 | 46d | 0d | start no later than 2009-04-28 | Hall C Tech's | 8h | ITHA Req'd | 1 |  |  |  |
| 124 | Align photon beam line | 1d? | 2009-04-29 | 2009-04-29 | 47d | 0d | start no later than 2009-04-29 | Alignment Group | 8h | ITHA Req'd | 1 |  |  |  |
| 125 | Place lead bricks around photon beam pipe on platform | 1d? | 2009-04-28 | 2009-04-28 | 46d | 0d | start no later than 2009-04-28 | Hall C Tech's | 8h | ITHA Req'd | 2 | Local |  |  |
| 126 | Place upper layer of shielding blocks around HKS detc. Table < Evening shift > | 2d | 2009-04-29 | 2009-04-30 | 47d | 0d | start no later than 2009-04-29 | Lockwood / Hall C Tech's | 16h | THA Req'd | 2 | Hall C |  |  |
| 127 | Mount drift chambers and hodoscope to HES magnet | 1d? | 2009-04-29 | 2009-04-29 | 47d | 0d | finish no later than 2009-04-29 | Hall-C techs / experimenters | 8h | THA Req'd | 2 | Local |  |  |
| 128 | Start placing and connection detector cables | 7d? | 2009-04-30 | 2009-05-08 | 48d | 0d | finish no later than 2009-05-08 | Experimenters | 56h | ITHA Req'd | 1 |  |  |  |
| 129 | Align HES drift chambers and hodoscope | 1d? | 2009-04-30 | 2009-04-30 | 48d | 0d | start no later than 2009-04-30 | Alignment Group | 8h | ITHA Req'd | 1 |  |  |  |
| 130 | Bolt HKS drift chamber frame to HKS dipole | 1d? | 2009-04-30 | 2009-04-30 | 48d | 0d | start no later than 2009-04-30 | Hall C Tech's | 8h | ITHA Req'd | 1 | Local |  |  |
| 131 | Install HKS drift chambers | 1d? | 2009-04-30 | 2009-04-30 | 48d | 0d | start no later than 2009-04-30 | Hall C Tech's | 8h | THA Req'd | 2 | Local |  |  |
| 132 | Align drift chambers | 1d? | 2009-05-01 | 2009-05-01 | 49d | 0d | start no later than 2009-05-01 | Alignment Group | 8h | ITHA Req'd | 1 |  |  |  |
| 133 | Crane in HKS detector stack assembly | 1d? | 2009-05-04 | 2009-05-04 | 50d | 0d | start no later than 2009-05-04 | Hall-C tech's | 8h | THA Req'd | 2 | Hall C |  |  |
| 134 | Align and secure detector stack | 1d? | 2009-05-04 | 2009-05-04 | 50d | 0d | start no later than 2009-05-04 | Align. Group / Hall C Tech's | 8h | ITHA Req'd | 1 |  |  |  |
| 135 | Weld angle brackets to detector support structure to secure alignment | 1d? | 2009-05-05 | 2009-05-05 | 51d | 0d | start no later than 2009-05-05 | Hall C Tech's | 8h | ITHA Req'd | 2 |  |  | Req'd |
| 136 | Complete shielding between HKS magnet and shield hut < Evening shift > | 2d | 2009-05-04 | 2009-05-05 | 50d | 0d | start no later than 2009-05-04 | Lockwood / Hall C Tech's | 16h | THA Req'd | 2 | Hall C |  |  |
| 137 | Start installing HKS and HES detector and high voltage cables | 8d? | 2009-05-06 | 2009-05-15 | 52d | 0d | finish no later than 2009-05-15 | Experimenters | 64h | ITHA Req'd | 1 |  |  |  |
| 138 | Build HKS shield hut entrance < Evening shift > | 2d? | 2009-05-06 | 2009-05-07 | 52d | 0d | finish no later than 2009-05-07 | Lockwood / Hall C Tech's | 16h | THA Req'd | 2 | Hall C |  |  |
| 139 | Install 24" beam line from DW to dump and leak check | 2d? | 2009-05-06 | 2009-05-07 | 52d | 0d | finish no later than 2009-05-07 | Hall C Tech's | 16h | ITHA Req'd | 1 |  |  |  |
| 140 | RADCON support required | 2d | 2009-05-05 | 2009-05-06 | 51d | 0d | start no later than 2009-05-05 | RADCON | 16h | ITHA Req'd | 0 |  |  |  |

| ID | Task | Duration | Start | Finish | Total slack | Free slack | Constraint | Resources | Work | Hard Hat & Safety Shoe Area | Text7 | Text17 | Text12 | Text2 |
| --- | --- | --- | --- | --- | --- | --- | --- | --- | --- | --- | --- | --- | --- | --- |
| 141 | Place HKS & HES and 2 FZ power supplies in final position | 2d? | 2009-05-07 | 2009-05-08 | 53d | 0d | finish no later than 2009-05-08 | Hall C Tech's | 16h | ITHA Req'd | 1 | Hall C |  |  |
| 142 | Connect LCW to HES, HKS, Splitter, DW magnet and power supplies | 3d | 2009-05-21 | 2009-05-25 | 63d | 0d | start no later than 2009-05-21 | ACC Tech's / Hall C Tech's | 24h | ITHA Req'd | 1 |  |  |  |
| 143 | Finish installing all cable trays as per drawing | 5d? | 2009-05-11 | 2009-05-15 | 55d | 0d | finish no later than 2009-05-15 | ACC Tech's / Hall C Tech's | 40h | ITHA Req'd | 2 | Hall C |  |  |
| 144 | Electrical connection to power supplies and magnets | 4d? | 2009-05-15 | 2009-05-20 | 59d | 0d | finish no later than 2009-05-20 | ACC tech's | 32h | ITHA Req'd | 1 |  |  |  |
| 145 | General Hall C cleanup (for photos by Greg A.) | 1d | 2009-05-18 | 2009-05-18 | 60d | 0d | start no later than 2009-05-18 | Hall C Tech's | 8h | ITHA Req'd | 0 |  |  |  |
| 146 | Test HES, HKS and splitter magnets power supplies and ramp up magnets | 1d? | 2009-05-19 | 2009-05-19 | 61d | 0d | start no later than 2009-05-19 | Experimenters/ H C Tech's | 8h | ITHA Req'd | 2 |  | TOSP Req'd |  |
| 147 | Take Photos with Greg Adams for HKS Hall C poster | 0.1d? | 2009-05-19 | 2009-05-19 | 61d | 0d | start no later than 2009-05-19 | Hall C Tech's / Greg Adams | 0.8h | ITHA Req'd | 1 | Hall C |  |  |
| 148 | Complete HKS and HES shield hut, place roof beams < Evening shift > | 4d | 2009-05-11 | 2009-05-14 | 55d | 0d | finish no later than 2009-05-14 | Lockwood / Hall C Tech's | 32h | THA Req'd | 2 | Hall C |  |  |
| 149 | Set up gas connection HES and HKS wire chambers | 2d? | 2009-05-14 | 2009-05-15 | 58d | 0d | finish no later than 2009-05-15 | Hall C Tech's / Experim. | 16h | ITHA Req'd | 1 |  |  |  |
| 150 | Install fans and A/C in shield huts where needed | 1d? | 2009-05-18 | 2009-05-18 | 60d | 0d | start no later than 2009-05-18 | Hall C Tech's | 8h | ITHA Req'd | 1 |  |  |  |
| 151 | Install Electric power, lights and PPS in all shield huts | 5d? | 2009-05-19 | 2009-05-25 | 61d | 0d | finish no later than 2009-05-25 | ACC tech's | 40h | ITHA Req'd | 1 |  |  | Req'd |
| 152 | Cut and install small section of SOS rail | 1d? | 2009-05-18 | 2009-05-18 | 60d | 0d | finish no later than 2009-05-18 | Hall C Tech's | 8h | ITHA Req'd | 2 | Hall C |  |  |
| 153 | Align SOS rail | 1d? | 2009-05-19 | 2009-05-19 | 61d | 0d | finish no later than 2009-05-19 | Alignment Group / Hall C Tech's | 8h | ITHA Req'd | 1 |  |  |  |
| 154 | Set up and connect all vacuum pumps | 2d? | 2009-05-19 | 2009-05-20 | 61d | 0d | finish no later than 2009-05-20 | Hall-C tech's | 16h | ITHA Req'd | 1 | Local |  |  |
| 155 | Move SOS to ??? deg. to clear for beam line on pivot | 1d? | 2009-06-16 | 2009-06-16 | 81d | 0d | start no later than 2009-06-16 | Hall-C tech's / design group | 8h | ITHA Req'd | 2 |  |  | Req'd |
| 156 | Install and connect beam line section over the pivot | 4d? | 2009-06-17 | 2009-06-22 | 82d | 0d | finish no later than 2009-06-22 | ACC Tech's / Hall C Tech's | 32h | ITHA Req'd | 1 |  |  | Req'd |
| 157 | Final Hall C elevation check | 2d | 2009-07-06 | 2009-07-07 | 95d | 0d | finish no later than 2009-07-07 | Alignment Group | 16h | ITHA Req'd | 1 |  |  |  |
| 158 | Final Hall C general alignment check | 2d | 2009-07-15 | 2009-07-16 | 102d | 0d | start no later than 2009-07-15 | Alignment Group | 16h | ITHA Req'd | 1 |  |  |  |
| 159 | Clean up Hall C, remove lifts, ladders, slings etc. | 2d? | 2009-07-20 | 2009-07-21 | 105d | 0d | finish no later than 2009-07-21 | Hall-C tech's | 16h | ITHA Req'd | 2 | Hall C |  |  |
| 160 | Up stream Beam Line installation ( contact Neil Wilson) | 95d | 2009-03-12 | 2009-07-22 | 13d | 0d | finish no later than 2009-07-22 | ACC tech's | 760h |  |  |  |  |  |
| 161 | SOS disassembly work when suitable | 95d | 2009-03-12 | 2009-07-22 | 13d | 0d | finish no later than 2009-07-22 | Lockwood / Hall C Tech's | 760h |  |  |  |  |  |
| 162 | Remove all electrical panels, cables, lights etc. (after doors are open, line 18) | 29d? | 2009-03-23 | 2009-04-30 | 20d | 0d | finish no later than 2009-04-30 | ACC Tech's / Hall C Tech's | 232h | ITHA Req'd | 2 | Local |  | Req'd |
| 163 | Remove SOS A/C and Hydraulic pump, tank and pipes < Evening shift > | 2d | 2009-05-18 | 2009-05-19 | 60d | 0d | start no later than 2009-05-18 | Lockwood / Hall C Tech's | 16h | THA Req'd | 2 | Hall C |  | Req'd |
| 164 | RADCON support required | 2d | 2009-05-18 | 2009-05-19 | 60d | 0d | start no later than 2009-05-18 | RADCON | 16h | ITHA Req'd | 0 |  |  | Req'd |
| 165 | Remove SOS doors and transport to bone yard < Evening shift > | 2d | 2009-05-20 | 2009-05-21 | 62d | 0d | start no later than 2009-05-20 | Lockwood / Hall C Tech's | 16h | THA Req'd | 2 | Hall C |  | Req'd |
| 166 | RADCON support required | 2d | 2009-05-20 | 2009-05-21 | 62d | 0d | start no later than 2009-05-20 | RADCON | 16h | ITHA Req'd | 0 |  |  | Req'd |
| 167 | Move SOS to ~ 90 deg for Lockwood to remove Hydraulic cylinders etc. | 1d? | 2009-05-25 | 2009-05-25 | 65d | 0d | start no later than 2009-05-25 | Hall-C tech's / design group | 8h | ITHA Req'd | 1 |  |  |  |
| 168 | Disassemble and move SOS Hydraulic cylinders out of Hall C < Evening shift > | 2d | 2009-05-18 | 2009-05-19 | 60d | 0d | start no later than 2009-05-18 | Lockwood / Hall C Tech's | 16h | THA Req'd | 2 | Hall C |  | Req'd |
| 169 | RADCON support required | 2d | 2009-05-18 | 2009-05-19 | 60d | 0d | finish no later than 2009-05-19 | RADCON | 16h | ITHA Req'd | 0 |  |  | Req'd |
| 170 | Move SOS back to clear truck ramp | 1d? | 2009-05-27 | 2009-05-27 | 67d | 0d | start no later than 2009-05-27 | Hall C Tech's | 8h | ITHA Req'd | 1 |  |  |  |
| 171 | HKS-HES Beam Line / Experiment Commissioning | 24d | 2009-07-21 | 2009-08-21 | 106d | 0d | start no later than 2009-07-21 | Experimenters | 192h |  |  |  |  |  |
| 172 | Test power supplies and magnets | 5d? | 2009-08-17 | 2009-08-21 | 74d | 0d | finish no earlier than 2009-05-11 | Experimenters | 40h |  |  |  |  |  |
